# Project-ScotiabankColpatria

Schedule from MS Project, 2021-01-04 to 2022-12-20, status date 2021-08-20, costs in $, A marks actual dates.

## Calendars

- Estándar: Mon-Fri 09:00-13:00, 15:00-19:00; Sat-Sun off. Exceptions (off unless hours are given): 2021-01-11 (Reyes Magos), 2021-03-22 (San José), 2021-04-01 (Jueves Santo), 2021-04-02 (Viernes Santo), 2021-05-01 (Dia del trabajo), 2021-05-17 (Dia de la asencion), 2021-06-07 (Corpues Cristi), 2021-06-14 (Sagrado corazon), 2021-07-05 (San pedro y san pablo), 2021-07-20 (Dia de a independencia), 2021-08-07 (Batalla de boyaca), 2021-08-16 (Asuncion de la Virgen), 2021-10-18 (Dia de la raza), 2021-11-01 (Dia de los difuntos), 2021-11-15 (Independencia de cartagena), 2021-12-08 (Inmaculada concepcion), 2021-12-25 (Navidad), 2022-01-01 (Año nuevo), 2022-01-10 (Reyes Magos), 2022-03-21 (San Jose), 2022-04-14 (Jueves Santo), 2022-04-15 (Viernes Santo), 2022-05-01 (Dia del trabajo), 2022-05-30 (Asencion), 2022-06-20 (Corpus Cristi), 2022-06-27 (Sagrado corazon), 2022-07-04 (San pedro y San pablo), 2022-07-20 (Independencia), 2022-08-07 (Batalla de Boyaca), 2022-08-15 (Asuncion de la Virgen), 2022-10-17 (Dia de l araza), 2022-11-07 (Todos los santos), 2022-11-14 (Independencia de cartagena), 2022-12-08 (Inmaculada concepcion).

## Resources

| Resource | Unit | Rate | Cost per use |
| --- | --- | --- | --- |
| Gerente del Proyecto |  | 35000 |  |
| Analista de infraestructura 1 |  | 11000 |  |
| Analista de infraestructura 2 |  | 11000 |  |
| Analista de operaciones 1 |  | 11000 |  |
| Analista de riesgos 1 |  | 11000 |  |
| Analista de riesgos 2 |  | 11000 |  |
| Asesor de cobranza 1 |  | 8300 |  |
| Asesor de cobranza 2 |  | 8300 |  |
| Asesor de cobranza 3 |  | 8300 |  |
| Asesor de cobranza 4 |  | 8300 |  |
| Analista de infraestructura 3 |  | 11000 |  |
| Abogado |  | 12500 |  |
| 14 Mesas | Unidad |  | 7000000 |
| Analista de infraestructura 4 |  | 11000 |  |
| Analista de fábrica de negociaciones 1 |  | 11000 |  |
| 14 Sillas | Unidad |  | 11200000 |
| 14 Portatil | Unidad |  | 35000000 |
| Papeleria 1 | Unidad |  | 1000000 |
| Licencias y actualizaciones de PC 1 | Unidad |  | 5000000 |

## Schedule

| ID | WBS | Task | Type | Duration | Start | Finish | Predecessors | Complete | Remaining | Baseline start | Baseline finish | Baseline duration | Total slack | Resources | Work | Actual work | Cost | Baseline cost | Actual cost | Duracion1 |
| --- | --- | --- | --- | --- | --- | --- | --- | --- | --- | --- | --- | --- | --- | --- | --- | --- | --- | --- | --- | --- |
| 1 | 1 | **REDISEÑO DE PROCESOS DE COBRANZA PARA EL MEJORAMIENTO DE LA CARTERA DE SCOTIABANK COLPATRIA** |  | 484d | 2021-01-04 A | 2022-12-20 |  | 26% | 357.42d | 2021-01-02 | 2022-12-20 | 484d | 0d | Licencias y actualizaciones de PC 1 [1 Unidad]; Papeleria 1 [1 Unidad]; 14 Mesas [1 Unidad]; 14 Portatil [1 Unidad]; 14 Sillas [1 Unidad] | 12424.8h | 3456.64h | 275,958,160 | 275,958,160 | 121,369,440 |  |
| 2 | 1.1 | INICIO | milestone | 0d | 2021-01-04 A | 2021-01-04 A |  | 100% |  | 2021-01-02 | 2021-01-02 | 0d |  |  |  |  |  |  |  |  |
| 3 | 1.2 | **1.1 INICIO DEL PROYECTO** |  | 42d | 2021-01-04 A | 2021-03-03 A |  | 100% |  | 2021-01-04 | 2021-03-03 | 42d |  |  | 887.2h | 887.2h | 15,327,200 | 15,327,200 | 15,327,200 |  |
| 4 | 1.2.1 | **Planeación estratégica** |  | 20d | 2021-01-04 A | 2021-02-01 A |  | 100% |  | 2021-01-04 | 2021-02-01 | 20d |  |  | 376h | 376h | 5,480,000 | 5,480,000 | 5,480,000 |  |
| 5 | 1.2.1.1 | Buscar información de la planeación estratégica del banco |  | 7d | 2021-01-04 A | 2021-01-13 A | 2 | 100% |  | 2021-01-04 | 2021-01-13 | 7d |  | Analista de infraestructura 1; Analista de infraestructura 2 | 112h | 112h | 1,232,000 | 1,232,000 | 1,232,000 | 3360 |
| 6 | 1.2.1.2 | Recopilación de documentos |  | 6d | 2021-01-14 A | 2021-01-21 A | 5 | 100% |  | 2021-01-14 | 2021-01-21 | 6d |  | Analista de infraestructura 2; Analista de infraestructura 1 | 96h | 96h | 1,056,000 | 1,056,000 | 1,056,000 | 2880 |
| 7 | 1.2.1.3 | Selección, análisis y organización de la información |  | 7d | 2021-01-22 A | 2021-02-01 A | 6 | 100% |  | 2021-01-22 | 2021-02-01 | 7d |  | Analista de infraestructura 1; Analista de infraestructura 2; Gerente del Proyecto | 168h | 168h | 3,192,000 | 3,192,000 | 3,192,000 | 3360 |
| 8 | 1.2.1.4 | Hito 1: Validar que la información encontrada sea verídica | milestone | 0d | 2021-02-01 A | 2021-02-01 A | 7 | 100% |  |  |  |  |  |  |  |  |  |  |  |  |
| 9 | 1.2.2 | **Identificar problemática general** |  | 6d | 2021-02-02 A | 2021-02-09 A |  | 100% |  | 2021-02-02 | 2021-02-09 | 6d |  |  | 144h | 144h | 2,736,000 | 2,736,000 | 2,736,000 |  |
| 10 | 1.2.2.1 | Identificar situaciones a mejorar |  | 2d | 2021-02-02 A | 2021-02-03 A | 7 | 100% |  | 2021-02-02 | 2021-02-03 | 2d |  | Analista de infraestructura 1; Analista de infraestructura 2; Gerente del Proyecto | 48h | 48h | 912,000 | 912,000 | 912,000 | 960 |
| 11 | 1.2.2.2 | Realizar árbol de problemas |  | 4d | 2021-02-04 A | 2021-02-09 A | 10 | 100% |  | 2021-02-04 | 2021-02-09 | 4d |  | Analista de infraestructura 1; Analista de infraestructura 2; Gerente del Proyecto | 96h | 96h | 1,824,000 | 1,824,000 | 1,824,000 | 1920 |
| 12 | 1.2.3 | **Planteamiento de soluciones** |  | 13d | 2021-02-10 A | 2021-02-26 A | 11 | 100% |  | 2021-02-10 | 2021-02-26 | 13d |  |  | 312h | 312h | 5,928,000 | 5,928,000 | 5,928,000 |  |
| 13 | 1.2.3.1 | Realizar lluvia de ideas |  | 3d | 2021-02-10 A | 2021-02-12 A | 11 | 100% |  | 2021-02-10 | 2021-02-12 | 3d |  | Analista de infraestructura 1; Analista de infraestructura 2; Gerente del Proyecto | 72h | 72h | 1,368,000 | 1,368,000 | 1,368,000 | 1440 |
| 14 | 1.2.3.2 | Realizar árbol de objetivos |  | 4d | 2021-02-15 A | 2021-02-18 A | 13 | 100% |  | 2021-02-15 | 2021-02-18 | 4d |  | Analista de infraestructura 1; Analista de infraestructura 2; Gerente del Proyecto | 96h | 96h | 1,824,000 | 1,824,000 | 1,824,000 | 1920 |
| 15 | 1.2.3.3 | Plantear soluciones |  | 6d | 2021-02-19 A | 2021-02-26 A | 14 | 100% |  | 2021-02-19 | 2021-02-26 | 6d |  | Analista de infraestructura 1; Analista de infraestructura 2; Gerente del Proyecto | 144h | 144h | 2,736,000 | 2,736,000 | 2,736,000 | 2880 |
| 16 | 1.2.4 | **Alternativa seleccionada** |  | 3d | 2021-03-01 A | 2021-03-03 A |  | 100% |  | 2021-03-01 | 2021-03-03 | 3d |  |  | 55.2h | 55.2h | 1,183,200 | 1,183,200 | 1,183,200 |  |
| 17 | 1.2.4.1 | Evaluar y Escoger alternativa. |  | 3d | 2021-03-01 A | 2021-03-03 A | 15 | 100% |  | 2021-03-01 | 2021-03-03 | 3d |  | Analista de infraestructura 2; Gerente del Proyecto; Analista de operaciones 1 [30%] | 55.2h | 55.2h | 1,183,200 | 1,183,200 | 1,183,200 | 1440 |
| 18 | 1.3 | **1.2 PLANEACIÓN DE DIRECCIÓN DEL PROYECTO** |  | 120d | 2021-03-04 A | 2021-08-31 |  | 87% | 15.29d | 2021-03-04 | 2021-08-31 | 120d | 0d |  | 3028.8h | 2569.44h | 55,224,240 | 55,224,240 | 46,842,240 |  |
| 19 | 1.3.1 | **Plan de gestión del alcance** |  | 22d | 2021-03-04 A | 2021-04-07 A |  | 100% |  | 2021-03-04 | 2021-04-07 | 22d |  |  | 487.2h | 487.2h | 8,623,200 | 8,623,200 | 8,623,200 |  |
| 20 | 1.3.1.1 | Identificar los procesos de gestión. |  | 4d | 2021-03-04 A | 2021-03-09 A | 17 | 100% |  | 2021-03-04 | 2021-03-09 | 4d |  | Analista de infraestructura 3 [10%] | 3.2h | 3.2h | 35,200 | 35,200 | 35,200 | 1920 |
| 21 | 1.3.1.2 | Definir los objetivos del proyecto. |  | 5d | 2021-03-04 A | 2021-03-10 A | 17 | 100% |  | 2021-03-04 | 2021-03-10 | 5d |  | Analista de infraestructura 4 [30%] | 12h | 12h | 132,000 | 132,000 | 132,000 | 2400 |
| 22 | 1.3.1.3 | Definir fases del proyecto. |  | 5d | 2021-03-04 A | 2021-03-10 A | 17 | 100% |  | 2021-03-04 | 2021-03-10 | 5d |  | Analista de infraestructura 2 | 40h | 40h | 440,000 | 440,000 | 440,000 | 2400 |
| 23 | 1.3.1.4 | Definir entregas del proyecto. |  | 3d | 2021-03-04 A | 2021-03-08 A | 17 | 100% |  | 2021-03-04 | 2021-03-08 | 3d |  | Analista de infraestructura 1; Gerente del Proyecto | 48h | 48h | 1,104,000 | 1,104,000 | 1,104,000 | 1440 |
| 24 | 1.3.1.5 | Recopilar Requisitos. |  | 3d | 2021-03-11 A | 2021-03-15 A | 21, 22, 23 | 100% |  | 2021-03-11 | 2021-03-15 | 3d |  | Analista de infraestructura 1; Analista de infraestructura 2 | 48h | 48h | 528,000 | 528,000 | 528,000 | 1440 |
| 25 | 1.3.1.6 | Planificar la Gestión del Alcance. |  | 4d | 2021-03-16 A | 2021-03-19 A | 24 | 100% |  | 2021-03-16 | 2021-03-19 | 4d |  | Analista de infraestructura 1; Analista de infraestructura 2; Gerente del Proyecto | 96h | 96h | 1,824,000 | 1,824,000 | 1,824,000 | 1920 |
| 26 | 1.3.1.7 | Definir el Alcance. |  | 4d | 2021-03-23 A | 2021-03-26 A | 25 | 100% |  | 2021-03-23 | 2021-03-26 | 4d |  | Analista de infraestructura 1; Analista de infraestructura 2; Gerente del Proyecto | 96h | 96h | 1,824,000 | 1,824,000 | 1,824,000 | 1920 |
| 27 | 1.3.1.8 | Crear la EDT (Estructura de Descomposición del Trabajo). |  | 2d | 2021-03-29 A | 2021-03-30 A | 26 | 100% |  | 2021-03-29 | 2021-03-30 | 2d |  | Analista de infraestructura 1; Analista de infraestructura 2; Gerente del Proyecto | 48h | 48h | 912,000 | 912,000 | 912,000 | 960 |
| 28 | 1.3.1.9 | Validar el Alcance. |  | 2d | 2021-03-31 A | 2021-04-05 A | 27 | 100% |  | 2021-03-31 | 2021-04-05 | 2d |  | Analista de infraestructura 1; Analista de infraestructura 2; Gerente del Proyecto | 48h | 48h | 912,000 | 912,000 | 912,000 | 960 |
| 29 | 1.3.1.10 | Definir mecanismos de control |  | 2d | 2021-04-06 A | 2021-04-07 A | 28 | 100% |  | 2021-04-06 | 2021-04-07 | 2d |  | Analista de infraestructura 1; Analista de infraestructura 2; Gerente del Proyecto | 48h | 48h | 912,000 | 912,000 | 912,000 | 960 |
| 30 | 1.3.1.11 | Hito 2: Controlar el Alcance. | milestone | 0d | 2021-04-07 A | 2021-04-07 A | 29 | 100% |  | 2021-04-07 | 2021-04-07 | 0d |  |  |  |  |  |  |  |  |

| ID | WBS | Task | Type | Duration | Start | Finish | Predecessors | Complete | Baseline start | Baseline finish | Baseline duration | Resources | Work | Actual work | Cost | Baseline cost | Actual cost | Duracion1 |
| --- | --- | --- | --- | --- | --- | --- | --- | --- | --- | --- | --- | --- | --- | --- | --- | --- | --- | --- |
| 31 | 1.3.2 | **Plan de gestión del tiempo** |  | 17d | 2021-04-08 A | 2021-04-30 A |  | 100% | 2021-04-08 | 2021-04-30 | 17d |  | 408h | 408h | 7,752,000 | 7,752,000 | 7,752,000 |  |
| 32 | 1.3.2.1 | Planificar la Gestión del Cronograma. |  | 4d | 2021-04-08 A | 2021-04-13 A | 30 | 100% | 2021-04-08 | 2021-04-13 | 4d | Analista de infraestructura 1; Analista de infraestructura 2; Gerente del Proyecto | 96h | 96h | 1,824,000 | 1,824,000 | 1,824,000 | 1920 |
| 33 | 1.3.2.2 | Definir actividades críticas del proyecto. |  | 3d | 2021-04-14 A | 2021-04-16 A | 32 | 100% | 2021-04-14 | 2021-04-16 | 3d | Analista de infraestructura 1; Analista de infraestructura 2; Gerente del Proyecto | 72h | 72h | 1,368,000 | 1,368,000 | 1,368,000 | 1440 |
| 34 | 1.3.2.3 | Secuenciar las Actividades. |  | 1d | 2021-04-19 A | 2021-04-19 A | 33 | 100% | 2021-04-19 | 2021-04-19 | 1d | Analista de infraestructura 1; Analista de infraestructura 2; Gerente del Proyecto | 24h | 24h | 456,000 | 456,000 | 456,000 | 480 |
| 35 | 1.3.2.4 | Estimar recursos de las Actividades. |  | 4d | 2021-04-20 A | 2021-04-23 A | 34 | 100% | 2021-04-20 | 2021-04-23 | 4d | Analista de infraestructura 1; Analista de infraestructura 2; Gerente del Proyecto | 96h | 96h | 1,824,000 | 1,824,000 | 1,824,000 | 1920 |
| 36 | 1.3.2.5 | Estimar la duración de las Actividades. |  | 4d | 2021-04-26 A | 2021-04-29 A | 35 | 100% | 2021-04-26 | 2021-04-29 | 4d | Analista de infraestructura 1; Analista de infraestructura 2; Gerente del Proyecto | 96h | 96h | 1,824,000 | 1,824,000 | 1,824,000 | 1920 |
| 37 | 1.3.2.6 | Crear el cronograma del proyecto |  | 1d | 2021-04-30 A | 2021-04-30 A | 33, 34, 35, 36 | 100% | 2021-04-30 | 2021-04-30 | 1d | Analista de infraestructura 1; Analista de infraestructura 2; Gerente del Proyecto | 24h | 24h | 456,000 | 456,000 | 456,000 | 480 |
| 38 | 1.3.2.7 | Hito 3: Controlar el Cronograma. | milestone | 0d | 2021-04-30 A | 2021-04-30 A | 37 | 100% | 2021-04-30 | 2021-04-30 | 0d |  |  |  |  |  |  |  |
| 39 | 1.3.3 | **Plan de gestión de costos** |  | 11d | 2021-05-03 A | 2021-05-18 A |  | 100% | 2021-05-03 | 2021-05-18 | 11d |  | 264h | 264h | 5,016,000 | 5,016,000 | 5,016,000 |  |
| 40 | 1.3.3.1 | Identificar los recursos necesarios para el proyecto |  | 3d | 2021-05-03 A | 2021-05-05 A | 38 | 100% | 2021-05-03 | 2021-05-05 | 3d | Analista de infraestructura 1; Analista de infraestructura 2; Gerente del Proyecto | 72h | 72h | 1,368,000 | 1,368,000 | 1,368,000 | 1440 |
| 41 | 1.3.3.2 | Definir la línea de costos |  | 2d | 2021-05-06 A | 2021-05-07 A | 40 | 100% | 2021-05-06 | 2021-05-07 | 2d | Analista de infraestructura 1; Analista de infraestructura 2; Gerente del Proyecto | 48h | 48h | 912,000 | 912,000 | 912,000 | 960 |
| 42 | 1.3.3.3 | Estimar los costos del proyecto |  | 3d | 2021-05-10 A | 2021-05-12 A | 41 | 100% | 2021-05-10 | 2021-05-12 | 3d | Analista de infraestructura 1; Analista de infraestructura 2; Gerente del Proyecto | 72h | 72h | 1,368,000 | 1,368,000 | 1,368,000 | 1440 |
| 43 | 1.3.3.4 | Determinar el presupuesto del proyecto |  | 2d | 2021-05-13 A | 2021-05-14 A | 42 | 100% | 2021-05-13 | 2021-05-14 | 2d | Analista de infraestructura 1; Analista de infraestructura 2; Gerente del Proyecto | 48h | 48h | 912,000 | 912,000 | 912,000 | 960 |
| 44 | 1.3.3.5 | Definir plan de control de costos |  | 1d | 2021-05-18 A | 2021-05-18 A | 43 | 100% | 2021-05-18 | 2021-05-18 | 1d | Analista de infraestructura 1; Analista de infraestructura 2; Gerente del Proyecto | 24h | 24h | 456,000 | 456,000 | 456,000 | 480 |
| 45 | 1.3.3.6 | Hito 4: Controlar el costo. | milestone | 0d | 2021-05-18 A | 2021-05-18 A | 44 | 100% | 2021-05-18 | 2021-05-18 | 0d |  |  |  |  |  |  |  |
| 46 | 1.3.4 | **Plan de gestión de la calidad** |  | 8d | 2021-05-19 A | 2021-05-28 A |  | 100% | 2021-05-19 | 2021-05-28 | 8d |  | 247.2h | 247.2h | 4,240,080 | 4,240,080 | 4,240,080 |  |
| 47 | 1.3.4.1 | Establecer estándares y normatividad |  | 4d | 2021-05-19 A | 2021-05-24 A | 45 | 100% | 2021-05-19 | 2021-05-24 | 4d | Analista de infraestructura 1; Analista de infraestructura 2; Gerente del Proyecto | 96h | 96h | 1,824,000 | 1,824,000 | 1,824,000 | 1920 |
| 48 | 1.3.4.2 | Implementar medios de control |  | 1d | 2021-05-25 A | 2021-05-25 A | 47 | 100% | 2021-05-25 | 2021-05-25 | 1d | Analista de infraestructura 1; Analista de infraestructura 2; Gerente del Proyecto | 24h | 24h | 456,000 | 456,000 | 456,000 | 480 |
| 49 | 1.3.4.3 | Definir roles y responsabilidades |  | 3d | 2021-05-26 A | 2021-05-28 A | 48 | 100% | 2021-05-26 | 2021-05-28 | 3d | Analista de infraestructura 1; Analista de infraestructura 2; Gerente del Proyecto; Abogado [30%]; Analista de infraestructura 4 [30%]; Analista de fábrica de negociaciones 1 [30%]; Analista de operaciones 1 [30%]; Analista de riesgos 1 [30%]; Analista de riesgos 2 [30%]; Asesor de cobranza 1 [10%]; Asesor de cobranza 2 [10%]; Asesor de cobranza 3 [10%]; Asesor de cobranza 4 [10%]; Analista de infraestructura 3 [10%] | 127.2h | 127.2h | 1,960,080 | 1,960,080 | 1,960,080 | 1440 |
| 50 | 1.3.5 | **Plan de gestión de recursos** |  | 4d | 2021-05-31 A | 2021-06-03 A |  | 100% | 2021-05-31 | 2021-06-03 | 4d |  | 65.6h | 65.6h | 1,297,600 | 1,297,600 | 1,297,600 |  |
| 51 | 1.3.5.1 | Identificar los recursos necesarios |  | 2d | 2021-05-31 A | 2021-06-01 A | 49 | 100% | 2021-05-31 | 2021-06-01 | 2d | Analista de infraestructura 1 | 16h | 16h | 176,000 | 176,000 | 176,000 | 960 |
| 52 | 1.3.5.2 | Definir organigrama |  | 1d | 2021-05-31 A | 2021-05-31 A | 48, 49 | 100% | 2021-05-31 | 2021-05-31 | 1d | Analista de infraestructura 2; Gerente del Proyecto | 16h | 16h | 368,000 | 368,000 | 368,000 | 480 |
| 53 | 1.3.5.3 | Definir capacitaciones del proyecto |  | 2d | 2021-06-01 A | 2021-06-02 A | 52 | 100% | 2021-06-01 | 2021-06-02 | 2d | Analista de infraestructura 2; Gerente del Proyecto | 32h | 32h | 736,000 | 736,000 | 736,000 | 960 |
| 54 | 1.3.5.4 | Definir perfiles del proyecto |  | 2d | 2021-06-02 A | 2021-06-03 A | 53FS-5%, 52 | 100% | 2021-06-02 | 2021-06-03 | 2d | Analista de infraestructura 3 [10%] | 1.6h | 1.6h | 17,600 | 17,600 | 17,600 | 960 |
| 55 | 1.3.5.5 | Hito 5: Controlar el costo. | milestone | 0d | 2021-06-03 A | 2021-06-03 A | 54 | 100% | 2021-06-03 | 2021-06-03 | 0d |  |  |  |  |  |  |  |

| ID | WBS | Task | Type | Duration | Start | Finish | Predecessors | Complete | Remaining | Baseline start | Baseline finish | Baseline duration | Total slack | Free slack | Resources | Work | Actual work | Cost | Baseline cost | Actual cost | Duracion1 |
| --- | --- | --- | --- | --- | --- | --- | --- | --- | --- | --- | --- | --- | --- | --- | --- | --- | --- | --- | --- | --- | --- |
| 56 | 1.3.6 | **Plan de gestión de comunicaciones** |  | 4d | 2021-06-04 A | 2021-06-10 A |  | 100% |  | 2021-06-04 | 2021-06-10 | 4d |  |  |  | 114.4h | 114.4h | 2,021,360 | 2,021,360 | 2,021,360 |  |
| 57 | 1.3.6.1 | Elaborar plan de comunicaciones |  | 2d | 2021-06-04 A | 2021-06-08 A | 55 | 100% |  | 2021-06-04 | 2021-06-08 | 2d |  |  | Analista de infraestructura 1; Analista de infraestructura 2; Gerente del Proyecto | 48h | 48h | 912,000 | 912,000 | 912,000 | 960 |
| 58 | 1.3.6.2 | Definir métodos o tecnologías utilizados para transmitir la información |  | 1d | 2021-06-09 A | 2021-06-09 A | 57 | 100% |  | 2021-06-09 | 2021-06-09 | 1d |  |  | Analista de infraestructura 1; Analista de infraestructura 2; Gerente del Proyecto | 24h | 24h | 456,000 | 456,000 | 456,000 | 480 |
| 59 | 1.3.6.3 | Difundir el sistema de comunicación |  | 1d | 2021-06-10 A | 2021-06-10 A | 58 | 100% |  | 2021-06-10 | 2021-06-10 | 1d |  |  | Analista de infraestructura 1; Analista de infraestructura 2; Gerente del Proyecto; Abogado [30%]; Analista de infraestructura 4 [30%]; Analista de fábrica de negociaciones 1 [30%]; Analista de operaciones 1 [30%]; Analista de riesgos 1 [30%]; Analista de riesgos 2 [30%]; Asesor de cobranza 1 [10%]; Asesor de cobranza 2 [10%]; Asesor de cobranza 3 [10%]; Asesor de cobranza 4 [10%]; Analista de infraestructura 3 [10%] | 42.4h | 42.4h | 653,360 | 653,360 | 653,360 | 480 |
| 60 | 1.3.6.4 | Hito 6: Controlar las comunicaciones. | milestone | 0d | 2021-06-10 A | 2021-06-10 A | 59 | 100% |  | 2021-06-10 | 2021-06-10 | 0d |  |  |  |  |  |  |  |  |  |
| 61 | 1.3.7 | **Plan de gestión ambiental** |  | 10d | 2021-06-11 A | 2021-06-25 A | 60 | 100% |  | 2021-06-11 | 2021-06-25 | 10d |  |  |  | 240h | 240h | 4,560,000 | 4,560,000 | 4,560,000 |  |
| 62 | 1.3.7.1 | Identificar factores ambientales de la empresa |  | 5d | 2021-06-11 A | 2021-06-18 A | 29 | 100% |  | 2021-06-11 | 2021-06-18 | 5d |  |  | Analista de infraestructura 1; Analista de infraestructura 2; Gerente del Proyecto | 120h | 120h | 2,280,000 | 2,280,000 | 2,280,000 | 2400 |
| 63 | 1.3.7.2 | Planificar y/o diseñar estrategias contra efectos ambientales negativos |  | 3d | 2021-06-21 A | 2021-06-23 A | 62 | 100% |  | 2021-06-21 | 2021-06-23 | 3d |  |  | Analista de infraestructura 1; Analista de infraestructura 2; Gerente del Proyecto | 72h | 72h | 1,368,000 | 1,368,000 | 1,368,000 | 1440 |
| 64 | 1.3.7.3 | Coordinar procesos |  | 2d | 2021-06-24 A | 2021-06-25 A | 63 | 100% |  | 2021-06-24 | 2021-06-25 | 2d |  |  | Analista de infraestructura 1; Analista de infraestructura 2; Gerente del Proyecto | 48h | 48h | 912,000 | 912,000 | 912,000 | 960 |
| 65 | 1.3.7.4 | Hito 7: Controlar factores ambientales. | milestone | 0d | 2021-06-25 A | 2021-06-25 A | 64 | 100% |  | 2021-06-25 | 2021-06-25 | 0d |  |  |  |  |  |  |  |  |  |
| 66 | 1.3.8 | **Plan de gestión de riesgos** |  | 25d | 2021-06-28 A | 2021-08-03 |  | 76% | 6d | 2021-06-28 | 2021-08-03 | 25d | 0d |  |  | 720h | 547.2h | 12,720,000 | 12,720,000 | 9,667,200 |  |
| 67 | 1.3.8.1 | Identificar riesgos |  | 4d | 2021-06-28 A | 2021-07-01 A | 29, 34, 44, 53, 59, 64 | 100% |  | 2021-06-28 | 2021-07-01 | 4d |  |  | Analista de infraestructura 1; Analista de infraestructura 2; Gerente del Proyecto; Analista de riesgos 1 [30%]; Analista de riesgos 2 [30%] | 115.2h | 115.2h | 2,035,200 | 2,035,200 | 2,035,200 | 1920 |
| 68 | 1.3.8.2 | Descripción de riesgos |  | 4d | 2021-07-02 A | 2021-07-08 A | 67 | 100% |  | 2021-07-02 | 2021-07-08 | 4d |  |  | Analista de infraestructura 1; Analista de infraestructura 2; Gerente del Proyecto; Analista de riesgos 1 [30%]; Analista de riesgos 2 [30%] | 115.2h | 115.2h | 2,035,200 | 2,035,200 | 2,035,200 | 1920 |
| 69 | 1.3.8.3 | Evaluar causas de los riesgos |  | 4d | 2021-07-09 A | 2021-07-14 A | 68 | 100% |  | 2021-07-09 | 2021-07-14 | 4d |  |  | Analista de infraestructura 1; Analista de infraestructura 2; Gerente del Proyecto; Analista de riesgos 1 [30%]; Analista de riesgos 2 [30%] | 115.2h | 115.2h | 2,035,200 | 2,035,200 | 2,035,200 | 1920 |
| 70 | 1.3.8.4 | Enlistar causas de los riesgos |  | 1d | 2021-07-15 A | 2021-07-15 A | 69 | 100% |  | 2021-07-15 | 2021-07-15 | 1d |  |  | Analista de infraestructura 1; Analista de infraestructura 2; Gerente del Proyecto; Analista de riesgos 1 [30%]; Analista de riesgos 2 [30%] | 28.8h | 28.8h | 508,800 | 508,800 | 508,800 | 480 |
| 71 | 1.3.8.5 | Definir roles y responsabilidades |  | 2d | 2021-07-16 A | 2021-07-19 | 70 | 50% | 1d | 2021-07-16 | 2021-07-19 | 2d | 1.5d | 0d | Analista de infraestructura 1; Analista de infraestructura 2; Gerente del Proyecto; Analista de riesgos 1 [30%]; Analista de riesgos 2 [30%] | 57.6h | 28.8h | 1,017,600 | 1,017,600 | 508,800 | 1920 |
| 72 | 1.3.8.6 | Crear planes de contingencia |  | 3d | 2021-07-21 A | 2021-07-23 | 71 | 50% | 1.5d | 2021-07-21 | 2021-07-23 | 3d | 1.5d | 0d | Analista de infraestructura 1; Analista de infraestructura 2; Gerente del Proyecto; Analista de riesgos 1 [30%]; Analista de riesgos 2 [30%] | 86.4h | 43.2h | 1,526,400 | 1,526,400 | 763,200 | 2880 |
| 73 | 1.3.8.7 | Generar planes de reserva |  | 3d | 2021-07-26 A | 2021-07-28 | 72 | 50% | 1.5d | 2021-07-26 | 2021-07-28 | 3d | 1d | 0d | Analista de infraestructura 1; Analista de infraestructura 2; Gerente del Proyecto; Analista de riesgos 1 [30%]; Analista de riesgos 2 [30%] | 86.4h | 43.2h | 1,526,400 | 1,526,400 | 763,200 | 2880 |
| 74 | 1.3.8.8 | Medir probabilidades de riesgo |  | 2d | 2021-07-29 A | 2021-07-30 | 73 | 50% | 1d | 2021-07-29 | 2021-07-30 | 2d | 1d | 0d | Analista de infraestructura 1; Analista de infraestructura 2; Gerente del Proyecto; Analista de riesgos 1 [30%]; Analista de riesgos 2 [30%] | 57.6h | 28.8h | 1,017,600 | 1,017,600 | 508,800 | 1920 |
| 75 | 1.3.8.9 | Generar auditoria del riesgo |  | 2d | 2021-08-02 A | 2021-08-03 | 74 | 50% | 1d | 2021-08-02 | 2021-08-03 | 2d | 0d |  | Analista de infraestructura 1; Analista de infraestructura 2; Gerente del Proyecto; Analista de riesgos 1 [30%]; Analista de riesgos 2 [30%] | 57.6h | 28.8h | 1,017,600 | 1,017,600 | 508,800 | 1920 |
| 76 | 1.3.8.10 | Hito 8: Controlar riesgos aceptados. | milestone | 0d | 2021-08-03 A | 2021-08-03 | 75 | 50% | 0d | 2021-08-03 | 2021-08-03 | 0d | 0d |  |  |  |  |  |  |  |  |
| 77 | 1.3.9 | **Plan de gestión de adquisiciones** |  | 19d | 2021-08-04 A | 2021-08-31 | 76 | 41% | 11.2d | 2021-08-04 | 2021-08-31 | 19d | 0d |  |  | 482.4h | 195.84h | 8,994,000 | 8,994,000 | 3,664,800 |  |
| 78 | 1.3.9.1 | Generar contratos |  | 6d | 2021-08-04 A | 2021-08-11 | 29 | 60% | 2.4d | 2021-08-04 | 2021-08-11 | 6d | 1.2d | 0d | Analista de infraestructura 1; Analista de infraestructura 2; Gerente del Proyecto; Abogado [30%] | 158.4h | 95.04h | 2,916,000 | 2,916,000 | 1,749,600 | 4800 |
| 79 | 1.3.9.2 | Generar plan de cambios |  | 2d | 2021-08-12 A | 2021-08-13 | 78 | 60% | 0.8d | 2021-08-12 | 2021-08-13 | 2d | 0.6d | 0d | Analista de infraestructura 1; Analista de infraestructura 2; Gerente del Proyecto | 48h | 28.8h | 912,000 | 912,000 | 547,200 | 1600 |
| 80 | 1.3.9.3 | Validar costos del servicio |  | 1d | 2021-08-17 A | 2021-08-17 | 79 | 60% | 0.4d | 2021-08-17 | 2021-08-17 | 1d | 2.4d | 0d | Analista de infraestructura 1; Analista de infraestructura 2; Gerente del Proyecto | 24h | 14.4h | 456,000 | 456,000 | 273,600 | 800 |
| 81 | 1.3.9.4 | Evaluar la mejor alternativa |  | 4d | 2021-08-18 A | 2021-08-23 | 80 | 60% | 1.6d | 2021-08-18 | 2021-08-23 | 4d | 0d |  | Analista de infraestructura 1; Analista de infraestructura 2; Gerente del Proyecto | 96h | 57.6h | 1,824,000 | 1,824,000 | 1,094,400 | 2200 |
| 82 | 1.3.9.5 | Contratación servicios |  | 3d | 2021-08-24 | 2021-08-26 | 81 |  |  | 2021-08-24 | 2021-08-26 | 3d | 0d |  | Analista de infraestructura 1; Analista de infraestructura 2; Gerente del Proyecto; Abogado [30%] | 79.2h |  | 1,458,000 | 1,458,000 |  |  |
| 83 | 1.3.9.6 | Realizar contrato |  | 1d | 2021-08-27 | 2021-08-27 | 82 |  |  | 2021-08-27 | 2021-08-27 | 1d | 0d |  | Analista de infraestructura 1; Analista de infraestructura 2; Gerente del Proyecto | 24h |  | 456,000 | 456,000 |  |  |
| 84 | 1.3.9.7 | Firmar contrato |  | 2d | 2021-08-30 | 2021-08-31 | 83 |  |  | 2021-08-30 | 2021-08-31 | 2d | 0d |  | Analista de infraestructura 1; Analista de infraestructura 2; Gerente del Proyecto; Abogado [30%] | 52.8h |  | 972,000 | 972,000 |  |  |
| 85 | 1.3.9.8 | Hito 9: Controlar adquisiones. | milestone | 0d | 2021-08-31 | 2021-08-31 | 84 |  |  | 2021-08-31 | 2021-08-31 | 0d | 0d |  |  |  |  |  |  |  |  |

| ID | WBS | Task | Type | Duration | Start | Finish | Predecessors | Baseline start | Baseline finish | Baseline duration | Total slack | Resources | Work | Cost | Baseline cost |
| --- | --- | --- | --- | --- | --- | --- | --- | --- | --- | --- | --- | --- | --- | --- | --- |
| 86 | 1.4 | **1.3 RECOPILACIÓN Y ANÁLISIS DE INFORMACIÓN** |  | 134d | 2021-09-01 | 2022-03-14 |  | 2021-09-01 | 2022-03-14 | 134d | 0d |  | 3933.6h | 68,890,320 | 68,890,320 |
| 87 | 1.4.1 | **1.3.1 Herramientas para la recolección de información** |  | 68d | 2021-09-01 | 2021-12-09 | 85 | 2021-09-01 | 2021-12-09 | 68d | 0d |  | 2301.6h | 38,266,320 | 38,266,320 |
| 88 | 1.4.1.1 | Revisión reportes de gestión |  | 2d | 2021-09-01 | 2021-09-02 | 29 | 2021-09-01 | 2021-09-02 | 2d | 0d | Analista de infraestructura 1; Analista de infraestructura 2; Gerente del Proyecto | 48h | 912,000 | 912,000 |
| 89 | 1.4.1.2 | Revisión estados financieros |  | 5d | 2021-09-03 | 2021-09-09 | 88 | 2021-09-03 | 2021-09-09 | 5d | 0d | Analista de infraestructura 1; Analista de infraestructura 2; Gerente del Proyecto | 120h | 2,280,000 | 2,280,000 |
| 90 | 1.4.1.3 | Revisión de manuales de procedimiento y políticas |  | 12d | 2021-09-10 | 2021-09-27 | 89 | 2021-09-10 | 2021-09-27 | 12d | 0d | Analista de infraestructura 1; Analista de infraestructura 2; Gerente del Proyecto; Analista de riesgos 1 [30%]; Analista de riesgos 2 [30%] | 345.6h | 6,105,600 | 6,105,600 |
| 91 | 1.4.1.4 | Diseñar estructura entrevista |  | 8d | 2021-09-28 | 2021-10-07 | 90 | 2021-09-28 | 2021-10-07 | 8d | 0d | Analista de infraestructura 1; Analista de infraestructura 2; Gerente del Proyecto | 192h | 3,648,000 | 3,648,000 |
| 92 | 1.4.1.5 | Efectuar entrevista |  | 12d | 2021-10-08 | 2021-10-26 | 91 | 2021-10-08 | 2021-10-26 | 12d | 0d | Analista de infraestructura 1; Analista de infraestructura 2; Gerente del Proyecto; Abogado [30%]; Analista de infraestructura 4 [30%]; Analista de fábrica de negociaciones 1 [30%]; Analista de operaciones 1 [30%]; Analista de riesgos 1 [30%]; Analista de riesgos 2 [30%]; Asesor de cobranza 1 [10%]; Asesor de cobranza 2 [10%]; Asesor de cobranza 3 [10%]; Asesor de cobranza 4 [10%]; Analista de infraestructura 3 [10%] | 508.8h | 7,840,320 | 7,840,320 |
| 93 | 1.4.1.6 | Diseñar estructura cuestionario |  | 6d | 2021-10-27 | 2021-11-04 | 92 | 2021-10-27 | 2021-11-04 | 6d | 0d | Analista de infraestructura 1; Analista de infraestructura 2; Gerente del Proyecto | 144h | 2,736,000 | 2,736,000 |
| 94 | 1.4.1.7 | Efectuar cuestionario |  | 15d | 2021-11-05 | 2021-11-26 | 93 | 2021-11-05 | 2021-11-26 | 15d | 0d | Analista de infraestructura 1; Analista de infraestructura 2; Gerente del Proyecto; Abogado [30%]; Analista de infraestructura 4 [30%]; Analista de fábrica de negociaciones 1 [30%]; Analista de operaciones 1 [30%]; Analista de riesgos 1 [30%]; Analista de riesgos 2 [30%]; Asesor de cobranza 1 [10%]; Asesor de cobranza 2 [10%]; Asesor de cobranza 3 [10%]; Asesor de cobranza 4 [10%]; Analista de infraestructura 3 [10%] | 636h | 9,800,400 | 9,800,400 |
| 95 | 1.4.1.8 | Generar mesas de trabajo |  | 8d | 2021-11-29 | 2021-12-09 | 94 | 2021-11-29 | 2021-12-09 | 8d | 0d | Analista de infraestructura 1; Analista de infraestructura 2; Gerente del Proyecto; Abogado [30%]; Analista de infraestructura 4 [30%]; Analista de fábrica de negociaciones 1 [30%]; Analista de operaciones 1 [30%]; Analista de riesgos 1 [30%]; Analista de riesgos 2 [30%] | 307.2h | 4,944,000 | 4,944,000 |
| 96 | 1.4.1.9 | Hito 9: Calidad de la data. | milestone | 0d | 2021-12-09 | 2021-12-09 | 95 | 2021-12-09 | 2021-12-09 | 0d | 0d |  |  |  |  |
| 97 | 1.4.2 | **1.3.2 Procesamiento de la información** |  | 21d | 2021-12-10 | 2022-01-07 |  | 2021-12-10 | 2022-01-07 | 21d | 0d |  | 504h | 9,576,000 | 9,576,000 |
| 98 | 1.4.2.1 | Analizar información. |  | 7d | 2021-12-10 | 2021-12-20 | 96 | 2021-12-10 | 2021-12-20 | 7d | 0d | Analista de infraestructura 1; Analista de infraestructura 2; Gerente del Proyecto | 168h | 3,192,000 | 3,192,000 |
| 99 | 1.4.2.2 | Elaborar informe de resultados. |  | 7d | 2021-12-21 | 2021-12-29 | 98 | 2021-12-21 | 2021-12-29 | 7d | 0d | Analista de infraestructura 1; Analista de infraestructura 2; Gerente del Proyecto | 168h | 3,192,000 | 3,192,000 |
| 100 | 1.4.2.3 | Obtener conclusiones. |  | 7d | 2021-12-30 | 2022-01-07 | 99 | 2021-12-30 | 2022-01-07 | 7d | 0d | Analista de infraestructura 1; Analista de infraestructura 2; Gerente del Proyecto | 168h | 3,192,000 | 3,192,000 |
| 101 | 1.4.3 | **1.3.3 Descripción procesos actuales** |  | 10d | 2022-01-11 | 2022-01-24 | 100 | 2022-01-11 | 2022-01-24 | 10d | 0d |  | 288h | 5,088,000 | 5,088,000 |
| 102 | 1.4.3.1 | Documentar manuales de procedimientos y políticas. |  | 10d | 2022-01-11 | 2022-01-24 | 29 | 2022-01-11 | 2022-01-24 | 10d | 0d | Analista de infraestructura 1; Analista de infraestructura 2; Gerente del Proyecto; Analista de riesgos 1 [30%]; Analista de riesgos 2 [30%] | 288h | 5,088,000 | 5,088,000 |
| 103 | 1.4.4 | **1.3.4 Comparativo de modelos de gestión de cobro** |  | 22d | 2022-01-25 | 2022-02-23 | 102 | 2022-01-25 | 2022-02-23 | 22d | 0d |  | 528h | 10,032,000 | 10,032,000 |
| 104 | 1.4.4.1 | Definir variables de comparación. |  | 8d | 2022-01-25 | 2022-02-03 | 100, 29 | 2022-01-25 | 2022-02-03 | 8d | 0d | Analista de infraestructura 1; Analista de infraestructura 2; Gerente del Proyecto | 192h | 3,648,000 | 3,648,000 |
| 105 | 1.4.4.2 | Ponderar las variables. |  | 4d | 2022-02-04 | 2022-02-09 | 104 | 2022-02-04 | 2022-02-09 | 4d | 0d | Analista de infraestructura 1; Analista de infraestructura 2; Gerente del Proyecto | 96h | 1,824,000 | 1,824,000 |
| 106 | 1.4.4.3 | Cotejar resultados. |  | 10d | 2022-02-10 | 2022-02-23 | 105 | 2022-02-10 | 2022-02-23 | 10d | 0d | Analista de infraestructura 1; Analista de infraestructura 2; Gerente del Proyecto | 240h | 4,560,000 | 4,560,000 |
| 107 | 1.4.5 | **1.3.5 Diagnóstico** |  | 13d | 2022-02-24 | 2022-03-14 | 106 | 2022-02-24 | 2022-03-14 | 13d | 0d |  | 312h | 5,928,000 | 5,928,000 |
| 108 | 1.4.5.1 | Identificar las buenas prácticas y deficiencias en los procesos. |  | 9d | 2022-02-24 | 2022-03-08 | 29, 105 | 2022-02-24 | 2022-03-08 | 9d | 0d | Analista de infraestructura 1; Analista de infraestructura 2; Gerente del Proyecto | 216h | 4,104,000 | 4,104,000 |
| 109 | 1.4.5.2 | Documentar el esquema de los procesos. |  | 4d | 2022-03-09 | 2022-03-14 | 108 | 2022-03-09 | 2022-03-14 | 4d | 0d | Analista de infraestructura 1; Analista de infraestructura 2; Gerente del Proyecto | 96h | 1,824,000 | 1,824,000 |

| ID | WBS | Task | Duration | Start | Finish | Predecessors | Baseline start | Baseline finish | Baseline duration | Total slack | Free slack | Constraint | Resources | Work | Cost | Baseline cost |
| --- | --- | --- | --- | --- | --- | --- | --- | --- | --- | --- | --- | --- | --- | --- | --- | --- |
| 110 | 1.5 | **1.4 MODELACIÓN** | 78d | 2022-03-15 | 2022-07-11 |  | 2022-03-15 | 2022-07-11 | 78d | 0d |  |  |  | 1944h | 34,490,400 | 34,490,400 |
| 111 | 1.5.1 | **1.4.1 Determinación nuevos objetivos de procesos** | 8.07d | 2022-03-15 | 2022-03-28 |  | 2022-03-15 | 2022-03-28 | 8.07d | 0d |  |  |  | 230.4h | 4,070,400 | 4,070,400 |
| 112 | 1.5.1.1 | Definir objetivos de procesos de gestión de cobro preventivo. | 8d | 2022-03-15 | 2022-03-25 | 109 | 2022-03-15 | 2022-03-25 | 8d | 166d | 0d |  | Analista de riesgos 1 [30%] | 19.2h | 211,200 | 211,200 |
| 113 | 1.5.1.2 | Definir objetivos de procesos de gestión de cobro de mora. | 8d | 2022-03-15 | 2022-03-28 | 109 | 2022-03-15 | 2022-03-28 | 8d | 165.93d | 0d | start no earlier than 2022-03-15 | Analista de infraestructura 2 | 64h | 704,000 | 704,000 |
| 114 | 1.5.1.3 | Definir objetivos de procesos de gestión de fábrica de negociaciones. | 8d | 2022-03-15 | 2022-03-25 | 109 | 2022-03-15 | 2022-03-25 | 8d | 166d | 0d |  | Analista de infraestructura 1; Gerente del Proyecto | 128h | 2,944,000 | 2,944,000 |
| 115 | 1.5.1.4 | Definir objetivos de procesos de gestión de cobro legal. | 8d | 2022-03-15 | 2022-03-25 | 109 | 2022-03-15 | 2022-03-25 | 8d | 0d |  |  | Analista de infraestructura 4 [30%] | 19.2h | 211,200 | 211,200 |
| 116 | 1.5.2 | **1.4.2 Determinación nuevos productos de procesos** | 8.07d | 2022-03-28 | 2022-04-07 |  | 2022-03-28 | 2022-04-07 | 8.07d | 0d |  |  |  | 230.4h | 4,070,400 | 4,070,400 |
| 117 | 1.5.2.1 | Definir productos de procesos de gestión de cobro preventivo. | 8d | 2022-03-28 | 2022-04-06 | 112 | 2022-03-28 | 2022-04-06 | 8d | 166d | 0d |  | Analista de infraestructura 1 | 64h | 704,000 | 704,000 |
| 118 | 1.5.2.2 | Definir productos de procesos de gestión de cobro de mora. | 8d | 2022-03-28 | 2022-04-07 | 113 | 2022-03-28 | 2022-04-07 | 8d | 165.93d | 0d |  | Analista de infraestructura 2; Gerente del Proyecto | 128h | 2,944,000 | 2,944,000 |
| 119 | 1.5.2.3 | Definir productos de procesos de gestión de fábrica de negociaciones. | 8d | 2022-03-28 | 2022-04-06 | 114 | 2022-03-28 | 2022-04-06 | 8d | 166d | 0d |  | Analista de fábrica de negociaciones 1 [30%] | 19.2h | 211,200 | 211,200 |
| 120 | 1.5.2.4 | Definir productos de procesos de gestión de cobro legal. | 8d | 2022-03-28 | 2022-04-06 | 115 | 2022-03-28 | 2022-04-06 | 8d | 0d |  |  | Analista de infraestructura 4 [30%] | 19.2h | 211,200 | 211,200 |
| 121 | 1.5.3 | **1.4.3 Determinación nuevos recursos de procesos** | 6.08d | 2022-04-07 | 2022-04-19 |  | 2022-04-07 | 2022-04-19 | 6.08d | 0d |  |  |  | 91.2h | 1,024,800 | 1,024,800 |
| 122 | 1.5.3.1 | Definir nuevos recursos de procesos de gestión de cobro preventivo. | 6d | 2022-04-07 | 2022-04-18 | 117 | 2022-04-07 | 2022-04-18 | 6d | 166d |  |  | Analista de operaciones 1 [30%] | 14.4h | 158,400 | 158,400 |
| 123 | 1.5.3.2 | Definir nuevos recursos de procesos de gestión de cobro de mora. | 6d | 2022-04-07 | 2022-04-19 | 118 | 2022-04-07 | 2022-04-19 | 6d | 165.93d |  |  | Analista de infraestructura 1 | 48h | 528,000 | 528,000 |
| 124 | 1.5.3.3 | Definir nuevos recursos de procesos de gestión de fábrica de negociaciones. | 6d | 2022-04-07 | 2022-04-18 | 119 | 2022-04-07 | 2022-04-18 | 6d | 166d |  |  | Analista de fábrica de negociaciones 1 [30%] | 14.4h | 158,400 | 158,400 |
| 125 | 1.5.3.4 | Definir nuevos recursos de procesos de gestión de cobro legal. | 6d | 2022-04-07 | 2022-04-18 | 120 | 2022-04-07 | 2022-04-18 | 6d | 0d |  |  | Abogado [30%] | 14.4h | 180,000 | 180,000 |
| 126 | 1.5.4 | **1.4.4 Diagramas de procesos** | 24d | 2022-04-19 | 2022-05-20 |  | 2022-04-19 | 2022-05-20 | 24d | 0d |  |  |  | 489.6h | 9,225,600 | 9,225,600 |
| 127 | 1.5.4.1 | Determinar los principales componentes del proceso. | 4d | 2022-04-19 | 2022-04-22 | 125 | 2022-04-19 | 2022-04-22 | 4d | 0d |  |  | Analista de infraestructura 4 [30%] | 9.6h | 105,600 | 105,600 |
| 128 | 1.5.4.2 | Ordenar las actividades. | 2d | 2022-04-25 | 2022-04-26 | 127 | 2022-04-25 | 2022-04-26 | 2d | 0d |  |  | Analista de infraestructura 1; Analista de infraestructura 2; Gerente del Proyecto | 48h | 912,000 | 912,000 |
| 129 | 1.5.4.3 | Generar la conexión entre las actividades. | 8d | 2022-04-27 | 2022-05-06 | 128 | 2022-04-27 | 2022-05-06 | 8d | 0d |  |  | Analista de infraestructura 1; Analista de infraestructura 2; Gerente del Proyecto | 192h | 3,648,000 | 3,648,000 |
| 130 | 1.5.4.4 | Indicar el comienzo y el final del proceso. | 7d | 2022-05-09 | 2022-05-17 | 129 | 2022-05-09 | 2022-05-17 | 7d | 0d |  |  | Analista de infraestructura 1; Analista de infraestructura 2; Gerente del Proyecto | 168h | 3,192,000 | 3,192,000 |
| 131 | 1.5.4.5 | Documentar diagrama. | 3d | 2022-05-18 | 2022-05-20 | 130 | 2022-05-18 | 2022-05-20 | 3d | 0d |  |  | Analista de infraestructura 1; Analista de infraestructura 2; Gerente del Proyecto | 72h | 1,368,000 | 1,368,000 |
| 132 | 1.5.5 | **1.4.5 Determinación nuevos excepciones de procesos** | 12d | 2022-05-23 | 2022-06-08 |  | 2022-05-23 | 2022-06-08 | 12d | 0d |  |  |  | 338.4h | 6,037,200 | 6,037,200 |
| 133 | 1.5.5.1 | Definir nuevas excepciones de procesos de gestión de cobro preventivo. | 3d | 2022-05-23 | 2022-05-25 | 131 | 2022-05-23 | 2022-05-25 | 3d | 0d |  |  | Analista de infraestructura 1; Analista de infraestructura 2; Gerente del Proyecto; Analista de operaciones 1 [30%]; Analista de riesgos 1 [30%] | 86.4h | 1,526,400 | 1,526,400 |
| 134 | 1.5.5.2 | Definir nuevas excepciones de procesos de gestión de cobro de mora. | 3d | 2022-05-26 | 2022-05-31 | 133 | 2022-05-26 | 2022-05-31 | 3d | 0d |  |  | Analista de infraestructura 1; Analista de infraestructura 2; Gerente del Proyecto; Analista de operaciones 1 [30%]; Analista de riesgos 2 [30%] | 86.4h | 1,526,400 | 1,526,400 |
| 135 | 1.5.5.3 | Definir nuevas excepciones de procesos de gestión de fábrica de negociaciones. | 3d | 2022-06-01 | 2022-06-03 | 134 | 2022-06-01 | 2022-06-03 | 3d | 0d |  |  | Analista de infraestructura 1; Analista de infraestructura 2; Gerente del Proyecto; Analista de infraestructura 4 [30%]; Analista de fábrica de negociaciones 1 [30%] | 86.4h | 1,526,400 | 1,526,400 |
| 136 | 1.5.5.4 | Definir nuevas excepciones de procesos de gestión de cobro legal. | 3d | 2022-06-06 | 2022-06-08 | 135 | 2022-06-06 | 2022-06-08 | 3d | 0d |  |  | Analista de infraestructura 1; Analista de infraestructura 2; Gerente del Proyecto; Abogado [30%] | 79.2h | 1,458,000 | 1,458,000 |

| ID | WBS | Task | Duration | Start | Finish | Predecessors | Baseline start | Baseline finish | Baseline duration | Total slack | Resources | Work | Cost | Baseline cost |
| --- | --- | --- | --- | --- | --- | --- | --- | --- | --- | --- | --- | --- | --- | --- |
| 137 | 1.5.6 | **1.4.6 Valor agregado del proceso** | 20d | 2022-06-09 | 2022-07-11 |  | 2022-06-09 | 2022-07-11 | 20d | 0d |  | 564h | 10,062,000 | 10,062,000 |
| 138 | 1.5.6.1 | Definir el valor agregado de procesos de gestión de cobro preventivo. | 5d | 2022-06-09 | 2022-06-15 | 136 | 2022-06-09 | 2022-06-15 | 5d | 0d | Analista de infraestructura 1; Analista de infraestructura 2; Gerente del Proyecto; Analista de operaciones 1 [30%]; Analista de riesgos 1 [30%] | 144h | 2,544,000 | 2,544,000 |
| 139 | 1.5.6.2 | Definir el valor agregado de procesos de gestión de cobro de mora. | 5d | 2022-06-16 | 2022-06-23 | 138 | 2022-06-16 | 2022-06-23 | 5d | 0d | Analista de infraestructura 1; Analista de infraestructura 2; Gerente del Proyecto; Analista de operaciones 1 [30%]; Analista de riesgos 2 [30%] | 144h | 2,544,000 | 2,544,000 |
| 140 | 1.5.6.3 | Definir el valor agregado de procesos de gestión de fábrica de negociaciones. | 5d | 2022-06-24 | 2022-07-01 | 139 | 2022-06-24 | 2022-07-01 | 5d | 0d | Analista de infraestructura 1; Analista de infraestructura 2; Gerente del Proyecto; Analista de infraestructura 4 [30%]; Analista de fábrica de negociaciones 1 [30%] | 144h | 2,544,000 | 2,544,000 |
| 141 | 1.5.6.4 | Definir el valor agregado de procesos de gestión de cobro legal. | 5d | 2022-07-05 | 2022-07-11 | 140 | 2022-07-05 | 2022-07-11 | 5d | 0d | Analista de infraestructura 1; Analista de infraestructura 2; Gerente del Proyecto; Abogado [30%] | 132h | 2,430,000 | 2,430,000 |
| 142 | 1.6 | **1.5 IMPLEMENTACIÓN** | 26d | 2022-07-12 | 2022-08-18 |  | 2022-07-12 | 2022-08-18 | 26d | 0d |  | 724.8h | 12,979,200 | 12,979,200 |
| 143 | 1.6.1 | **1.5.1 Asignación de responsabilidades** | 12d | 2022-07-12 | 2022-07-28 | 141 | 2022-07-12 | 2022-07-28 | 12d | 0d |  | 338.4h | 6,037,200 | 6,037,200 |
| 144 | 1.6.1.1 | Determinar responsabilidades de gestión de cobro preventivo. | 3d | 2022-07-12 | 2022-07-14 | 136 | 2022-07-12 | 2022-07-14 | 3d | 0d | Analista de infraestructura 1; Analista de infraestructura 2; Gerente del Proyecto; Analista de operaciones 1 [30%]; Analista de riesgos 1 [30%] | 86.4h | 1,526,400 | 1,526,400 |
| 145 | 1.6.1.2 | Determinar responsabilidades de gestión de cobro de mora. | 3d | 2022-07-15 | 2022-07-19 | 144 | 2022-07-15 | 2022-07-19 | 3d | 0d | Analista de infraestructura 1; Analista de infraestructura 2; Gerente del Proyecto; Analista de operaciones 1 [30%]; Analista de riesgos 2 [30%] | 86.4h | 1,526,400 | 1,526,400 |
| 146 | 1.6.1.3 | Determinar responsabilidades de gestión de fábrica de negociaciones. | 3d | 2022-07-21 | 2022-07-25 | 145 | 2022-07-21 | 2022-07-25 | 3d | 0d | Analista de infraestructura 1; Analista de infraestructura 2; Gerente del Proyecto; Analista de infraestructura 4 [30%]; Analista de fábrica de negociaciones 1 [30%] | 86.4h | 1,526,400 | 1,526,400 |
| 147 | 1.6.1.4 | Determinar responsabilidades de gestión de cobro legal. | 3d | 2022-07-26 | 2022-07-28 | 146 | 2022-07-26 | 2022-07-28 | 3d | 0d | Analista de infraestructura 1; Analista de infraestructura 2; Gerente del Proyecto; Abogado [30%] | 79.2h | 1,458,000 | 1,458,000 |
| 148 | 1.6.2 | **1.5.2 Plan de capacitación** | 14d | 2022-07-29 | 2022-08-18 |  | 2022-07-29 | 2022-08-18 | 14d | 0d |  | 386.4h | 6,942,000 | 6,942,000 |
| 149 | 1.6.2.1 | Definir las actividades a capacitar. | 3d | 2022-07-29 | 2022-08-02 | 147 | 2022-07-29 | 2022-08-02 | 3d | 0d | Analista de infraestructura 1; Analista de infraestructura 2; Gerente del Proyecto | 72h | 1,368,000 | 1,368,000 |
| 150 | 1.6.2.2 | Determinar el método de enseñanza. | 3d | 2022-08-03 | 2022-08-05 | 149 | 2022-08-03 | 2022-08-05 | 3d | 0d | Analista de infraestructura 1; Analista de infraestructura 2; Gerente del Proyecto; Analista de infraestructura 4 [30%]; Analista de fábrica de negociaciones 1 [30%]; Analista de operaciones 1 [30%]; Analista de riesgos 1 [30%]; Analista de riesgos 2 [30%] | 108h | 1,764,000 | 1,764,000 |
| 151 | 1.6.2.3 | Generar un cronograma de actividades. | 3d | 2022-08-08 | 2022-08-10 | 150 | 2022-08-08 | 2022-08-10 | 3d | 0d | Analista de infraestructura 1; Analista de infraestructura 2; Gerente del Proyecto | 72h | 1,368,000 | 1,368,000 |
| 152 | 1.6.2.4 | Delimitar el grupo de personas de la capacitación. | 3d | 2022-08-11 | 2022-08-16 | 151 | 2022-08-11 | 2022-08-16 | 3d | 0d | Analista de infraestructura 1; Analista de infraestructura 2; Gerente del Proyecto | 72h | 1,368,000 | 1,368,000 |
| 153 | 1.6.2.5 | Calcular los instructores necesarios para cada actividad del programa. | 1d | 2022-08-17 | 2022-08-17 | 152 | 2022-08-17 | 2022-08-17 | 1d | 0d | Analista de infraestructura 1; Analista de infraestructura 2; Gerente del Proyecto; Abogado [30%]; Analista de infraestructura 4 [30%]; Analista de fábrica de negociaciones 1 [30%]; Analista de operaciones 1 [30%]; Analista de riesgos 1 [30%]; Analista de riesgos 2 [30%] | 38.4h | 618,000 | 618,000 |
| 154 | 1.6.2.6 | Cuantificar los recursos (presupuesto e infraestructura). | 1d | 2022-08-18 | 2022-08-18 | 153 | 2022-08-18 | 2022-08-18 | 1d | 84d | Analista de infraestructura 1; Analista de infraestructura 2; Gerente del Proyecto | 24h | 456,000 | 456,000 |
| 155 | 1.7 | **1.6 EJECUCIÓN** | 15d | 2022-08-18 | 2022-09-07 |  | 2022-08-18 | 2022-09-07 | 15d | 0d |  | 192h | 2,036,400 | 2,036,400 |
| 156 | 1.7.1 | **1.6.1 Ejecución área cobro preventivo** | 15d | 2022-08-18 | 2022-09-07 |  | 2022-08-18 | 2022-09-07 | 15d | 0d |  | 60h | 595,200 | 595,200 |
| 157 | 1.7.1.1 | Modificar proceso actual cobro preventivo | 15d | 2022-08-18 | 2022-09-07 | 153 | 2022-08-18 | 2022-09-07 | 15d | 0d | Analista de riesgos 1 [30%]; Asesor de cobranza 1 [10%]; Asesor de cobranza 2 [10%] | 60h | 595,200 | 595,200 |
| 158 | 1.7.2 | **1.6.2 Ejecución área cobro moroso** | 15d | 2022-08-18 | 2022-09-07 |  | 2022-08-18 | 2022-09-07 | 15d | 0d |  | 60h | 595,200 | 595,200 |
| 159 | 1.7.2.1 | Modificar proceso actual cobro moroso | 15d | 2022-08-18 | 2022-09-07 | 153 | 2022-08-18 | 2022-09-07 | 15d | 0d | Analista de riesgos 2 [30%]; Asesor de cobranza 3 [10%]; Asesor de cobranza 4 [10%] | 60h | 595,200 | 595,200 |
| 160 | 1.7.3 | **1.6.3 Ejecución área fábrica de negociaciones** | 15d | 2022-08-18 | 2022-09-07 |  | 2022-08-18 | 2022-09-07 | 15d | 0d |  | 36h | 396,000 | 396,000 |
| 161 | 1.7.3.1 | Modificar proceso actual fábrica de negociaciones | 15d | 2022-08-18 | 2022-09-07 | 153 | 2022-08-18 | 2022-09-07 | 15d | 0d | Analista de fábrica de negociaciones 1 [30%] | 36h | 396,000 | 396,000 |

| ID | WBS | Task | Type | Duration | Start | Finish | Predecessors | Baseline start | Baseline finish | Baseline duration | Total slack | Resources | Work | Cost | Baseline cost |
| --- | --- | --- | --- | --- | --- | --- | --- | --- | --- | --- | --- | --- | --- | --- | --- |
| 162 | 1.7.4 | **1.6.4 Ejecución área cobro legal** |  | 15d | 2022-08-18 | 2022-09-07 |  | 2022-08-18 | 2022-09-07 | 15d | 0d |  | 36h | 450,000 | 450,000 |
| 163 | 1.7.4.1 | Modificar proceso actual cobro legal |  | 15d | 2022-08-18 | 2022-09-07 | 153 | 2022-08-18 | 2022-09-07 | 15d | 0d | Abogado [30%] | 36h | 450,000 | 450,000 |
| 164 | 1.8 | **1.7 CONTROL Y VERIFICACIÓN** |  | 52d | 2022-09-08 | 2022-11-23 |  | 2022-09-08 | 2022-11-23 | 52d | 0d |  | 1332h | 21,680,400 | 21,680,400 |
| 165 | 1.8.1 | **1.7.1 Detección de hallazgos** |  | 25d | 2022-09-08 | 2022-10-12 |  | 2022-09-08 | 2022-10-12 | 25d | 0d |  | 684h | 9,368,400 | 9,368,400 |
| 166 | 1.8.1.1 | Monitorear procesos nuevos. |  | 15d | 2022-09-08 | 2022-09-28 | 157, 159, 161, 163 | 2022-09-08 | 2022-09-28 | 15d | 0d | Analista de infraestructura 1; Analista de infraestructura 2; Abogado [30%]; Analista de infraestructura 4 [30%]; Analista de fábrica de negociaciones 1 [30%]; Analista de operaciones 1 [30%]; Asesor de cobranza 1 [10%]; Asesor de cobranza 2 [10%]; Asesor de cobranza 3 [10%]; Asesor de cobranza 4 [10%]; Analista de infraestructura 3 [10%] | 444h | 4,808,400 | 4,808,400 |
| 167 | 1.8.1.2 | Enlistar issues. |  | 5d | 2022-09-29 | 2022-10-05 | 166 | 2022-09-29 | 2022-10-05 | 5d | 0d | Analista de infraestructura 1; Analista de infraestructura 2; Gerente del Proyecto | 120h | 2,280,000 | 2,280,000 |
| 168 | 1.8.1.3 | Reportar problemáticas encontradas. |  | 5d | 2022-10-06 | 2022-10-12 | 167 | 2022-10-06 | 2022-10-12 | 5d | 0d | Analista de infraestructura 1; Analista de infraestructura 2; Gerente del Proyecto | 120h | 2,280,000 | 2,280,000 |
| 169 | 1.8.2 | **1.7.2 Correcciones de problemas** |  | 27d | 2022-10-13 | 2022-11-23 |  | 2022-10-13 | 2022-11-23 | 27d | 0d |  | 648h | 12,312,000 | 12,312,000 |
| 170 | 1.8.2.1 | Analizar las problemáticas reportadas. |  | 10d | 2022-10-13 | 2022-10-27 | 168 | 2022-10-13 | 2022-10-27 | 10d | 0d | Analista de infraestructura 1; Analista de infraestructura 2; Gerente del Proyecto | 240h | 4,560,000 | 4,560,000 |
| 171 | 1.8.2.2 | Determinar responsable del ajuste |  | 2d | 2022-10-28 | 2022-10-31 | 170 | 2022-10-28 | 2022-10-31 | 2d | 0d | Analista de infraestructura 1; Analista de infraestructura 2; Gerente del Proyecto | 48h | 912,000 | 912,000 |
| 172 | 1.8.2.3 | Ajustar problemática. |  | 15d | 2022-11-01 | 2022-11-23 | 171 | 2022-11-01 | 2022-11-23 | 15d | 0d | Analista de infraestructura 1; Analista de infraestructura 2; Gerente del Proyecto | 360h | 6,840,000 | 6,840,000 |
| 173 | 1.9 | **1.8 CIERRE DEL PROYECTO** |  | 18d | 2022-11-24 | 2022-12-20 |  | 2022-11-24 | 2022-12-20 | 18d | 0d |  | 382.4h | 6,130,000 | 6,130,000 |
| 174 | 1.9.1 | **1.8.1 Documentación cierre** |  | 18d | 2022-11-24 | 2022-12-20 |  | 2022-11-24 | 2022-12-20 | 18d | 0d |  | 382.4h | 6,130,000 | 6,130,000 |
| 175 | 1.9.1.1 | Documentar lecciones aprendidas. |  | 8d | 2022-11-24 | 2022-12-05 | 172 | 2022-11-24 | 2022-12-05 | 8d | 0d | Analista de infraestructura 1; Analista de infraestructura 2 | 128h | 1,408,000 | 1,408,000 |
| 176 | 1.9.1.2 | Realizar una sesión de lecciones aprendidas. |  | 1d | 2022-12-06 | 2022-12-06 | 175 | 2022-12-06 | 2022-12-06 | 1d | 0d | Analista de infraestructura 1; Analista de infraestructura 2; Gerente del Proyecto; Abogado [30%]; Analista de infraestructura 4 [30%]; Analista de fábrica de negociaciones 1 [30%]; Analista de operaciones 1 [30%]; Analista de riesgos 1 [30%]; Analista de riesgos 2 [30%] | 38.4h | 618,000 | 618,000 |
| 177 | 1.9.1.3 | Cerrar puntos abiertos. |  | 6d | 2022-12-07 | 2022-12-15 | 176 | 2022-12-07 | 2022-12-15 | 6d | 0d | Analista de infraestructura 1; Analista de infraestructura 2; Gerente del Proyecto | 144h | 2,736,000 | 2,736,000 |
| 178 | 1.9.1.4 | Conseguir aceptación. |  | 2d | 2022-12-16 | 2022-12-19 | 177 | 2022-12-16 | 2022-12-19 | 2d | 0d | Analista de infraestructura 1; Analista de infraestructura 2; Gerente del Proyecto | 48h | 912,000 | 912,000 |
| 179 | 1.9.1.5 | Oficializar aceptación del proyecto. |  | 1d | 2022-12-20 | 2022-12-20 | 178 | 2022-12-20 | 2022-12-20 | 1d | 0d | Analista de infraestructura 1; Analista de infraestructura 2; Gerente del Proyecto | 24h | 456,000 | 456,000 |
| 180 | 1.10 | FIN | milestone | 0d | 2022-12-20 | 2022-12-20 | 179 | 2022-12-20 | 2022-12-20 | 0d | 0d |  |  |  |  |
